# Schedule

Schedule from MS Project, 2004-08-17 to 2004-08-31.
RGII Technologies, Inc.

## Calendars

- Standard: Mon-Fri 08:00-12:00, 13:00-17:00; Sat-Sun off.

## Schedule

| ID | Task | Type | Duration | Start | Finish | Predecessors | Total slack | Constraint |
| --- | --- | --- | --- | --- | --- | --- | --- | --- |
| 1 | RFI Issued | milestone | 0d | 2004-08-17 | 2004-08-17 |  | 0d |  |
| 2 | First Draft |  | 3d | 2004-08-17 | 2004-08-19 | 1 | 0d | finish no earlier than 2004-08-19 |
| 3 | Blue Team |  | 1d? | 2004-08-20 | 2004-08-20 | 2 | 0d | start no earlier than 2004-08-20 |
| 4 | Final Draft |  | 4d | 2004-08-23 | 2004-08-26 | 3 | 0d | start no earlier than 2004-08-23 |
| 5 | Red Team |  | 1d? | 2004-08-27 | 2004-08-27 | 4 | 0d | start no earlier than 2004-08-27 |
| 6 | Red Team Recovery |  | 1d | 2004-08-30 | 2004-08-30 | 5 | 0d | start no earlier than 2004-08-30 |
| 7 | RFI Delivered | milestone | 0d | 2004-08-31 | 2004-08-31 | 6 | 0d | start no earlier than 2004-08-31 |
